# AnReVGapsInst04

Schedule from MS Project, 2003-08-19 to 2005-01-25.
CERN

## Calendars

- Standard: Mon-Fri 08:00-12:00, 13:00-17:00; Sat-Sun off.

## Schedule

| ID | WBS | Task | Duration | Start | Finish | Predecessors | Total slack | Free slack | Constraint |
| --- | --- | --- | --- | --- | --- | --- | --- | --- | --- |
| 1 | 1 | **RE1/2 (Positive)** | 230d | 2003-08-19 | 2004-07-05 |  | 146d |  |  |
| 2 | 1.1 | HPL production | 5d | 2003-08-19 | 2003-08-25 |  | 278d | 11d |  |
| 3 | 1.2 | HPL Rho measurement | 2d | 2003-09-10 | 2003-09-11 | 2 | 267d | 4d | start no earlier than 2003-09-10 |
| 4 | 1.3 | HPL Cut | 3d | 2003-09-18 | 2003-09-22 | 3 | 263d | 40d | start no earlier than 2003-09-18 |
| 5 | 1.4 | HPL Clean | 17d | 2003-11-18 | 2003-12-10 | 4 | 223d | 5d | start no earlier than 2003-11-18 |
| 6 | 1.5 | Ship to Korea | 6d | 2003-12-18 | 2003-12-25 | 5 | 218d | 58d | start no earlier than 2003-12-18 |
| 7 | 1.6 | Gap Assembly | 57d | 2004-03-17 | 2004-06-03 | 6 | 160d | 14d | start no earlier than 2004-03-17 |
| 8 | 1.7 | Gap ship to CERN | 8d | 2004-06-24 | 2004-07-05 | 7 | 146d |  | finish no earlier than 2004-07-05 |
| 9 | 2 | **On Yoke Chambers** | 312d | 2003-11-03 | 2005-01-11 |  | 10d |  |  |
| 10 | 2.1 | Chamber Assembly | 47d | 2004-07-19 | 2004-09-21 |  | 43d | 0d | start no earlier than 2004-07-19 |
| 11 | 2.2 | CosmicTesting | 62d | 2003-11-03 | 2004-10-28 |  | 58d | 48d | start no earlier than 2003-11-03 |
| 12 | 2.3 | On Yoke Installation | 5d | 2005-01-05 | 2005-01-11 | 11 | 10d |  | start no earlier than 2005-01-05 |
| 13 | 3 | **Off Yoke Chambers** | 1d? | 2003-08-19 | 2003-08-19 |  | 375d |  |  |
| 14 | 3.1 | ChamberAssembly | 1d? | 2003-08-19 | 2003-08-19 |  | 375d |  |  |
| 15 | 3.2 | CosmicTesting | 1d? | 2003-08-19 | 2003-08-19 |  | 375d |  |  |
| 16 | 3.3 | Off Yoke Installation | 1d? | 2003-08-19 | 2003-08-19 |  | 375d |  |  |
| 18 | 4 | **RE1/3 (Positive)** | 230d | 2003-08-19 | 2004-07-05 |  | 146d |  |  |
| 19 | 4.1 | HPL production | 5d | 2003-08-19 | 2003-08-25 |  | 278d | 11d |  |
| 20 | 4.2 | HPL Rho measurement | 2d | 2003-09-10 | 2003-09-11 | 19 | 267d | 4d | start no earlier than 2003-09-10 |
| 21 | 4.3 | HPL Cut | 3d | 2003-09-18 | 2003-09-22 | 20 | 263d | 40d | start no earlier than 2003-09-18 |
| 22 | 4.4 | HPL Clean | 17d | 2003-11-18 | 2003-12-10 | 21 | 223d | 5d | start no earlier than 2003-11-18 |
| 23 | 4.5 | Ship to Korea | 6d | 2003-12-18 | 2003-12-25 | 22 | 218d | 58d | start no earlier than 2003-12-18 |
| 24 | 4.6 | Gap Assembly | 57d | 2004-03-17 | 2004-06-03 | 23 | 160d | 14d | start no earlier than 2004-03-17 |
| 25 | 4.7 | Gap ship to CERN | 8d | 2004-06-24 | 2004-07-05 | 24 | 146d |  | finish no earlier than 2004-07-05 |

| ID | WBS | Task | Duration | Start | Finish | Predecessors | Total slack | Constraint |
| --- | --- | --- | --- | --- | --- | --- | --- | --- |
| 27 | 5 | **On Yoke Chambers** | 90d | 2004-09-22 | 2005-01-25 |  | 0d |  |
| 28 | 5.1 | Chamber Assembly | 47d | 2004-09-22 | 2004-11-25 | 10 | 43d |  |
| 29 | 5.2 | CosmicTesting | 52d | 2004-10-05 | 2004-12-15 |  | 29d | start no earlier than 2004-10-05 |
| 30 | 5.3 | On Yoke Installation | 5d | 2005-01-19 | 2005-01-25 |  | 0d | start no earlier than 2005-01-19 |
| 31 | 6 | **Off Yoke Chambers** | 1d? | 2003-08-19 | 2003-08-19 |  | 375d |  |
| 32 | 6.1 | ChamberAssembly | 1d? | 2003-08-19 | 2003-08-19 |  | 375d |  |
| 33 | 6.2 | CosmicTesting | 1d? | 2003-08-19 | 2003-08-19 |  | 375d |  |
| 34 | 6.3 | Off Yoke Installation | 1d? | 2003-08-19 | 2003-08-19 |  | 375d |  |
