# Overviewanrev04

Schedule from MS Project, 2004-06-08 to 2006-05-08.
CERN

## Calendars

- Standard: Mon-Fri 08:00-12:00, 13:00-17:00; Sat-Sun off.

## Schedule

| ID | WBS | Task | Duration | Start | Finish | Predecessors | Total slack | Free slack | Constraint |
| --- | --- | --- | --- | --- | --- | --- | --- | --- | --- |
| 1 | 1 | Install Cooling manifold | 11d? | 2004-06-08 | 2004-06-22 |  | 489d |  | finish no earlier than 2004-06-22 |
| 2 | 2 | Gap Delivery RE1/2 Pos. | 8d? | 2004-06-24 | 2004-07-05 |  | 480d |  | finish no earlier than 2004-07-05 |
| 3 | 3 | Gap Delivery RE1/2 Neg. | 9d? | 2004-12-03 | 2004-12-15 |  | 363d |  | finish no earlier than 2004-12-15 |
| 4 | 4 | Tested RE1/2 Pos. | 47d? | 2004-08-19 | 2004-10-22 | 2 | 347d | 0d | start no earlier than 2004-08-19 |
| 5 | 5 | Tested RE1/2 Neg | 36d? | 2005-10-12 | 2005-11-30 | 3 | 102d | 52d | finish no earlier than 2005-11-30 |
| 7 | 6 | Install Gas Pipes/Racks | 45d? | 2004-07-01 | 2004-09-01 |  | 438d |  | finish no earlier than 2004-09-01 |
| 8 | 7 | Gap delivery RE1/3 Pos. | 8d? | 2004-06-24 | 2004-07-05 |  | 480d |  | finish no earlier than 2004-07-05 |
| 9 | 8 | Gap delivery RE1/3 Neg. | 9d? | 2004-12-03 | 2004-12-15 |  | 363d |  | finish no earlier than 2004-12-15 |
| 10 | 9 | Tested RE1/3 Pos. | 38d? | 2004-10-25 | 2004-12-15 | 8, 4 | 347d | 33d | finish no earlier than 2004-11-25 |
| 11 | 10 | Tested RE1/3 Neg. | 41d? | 2005-12-01 | 2006-01-26 | 9 | 56d | 23d | finish no earlier than 2006-01-26 |
| 12 | 11 | Pipe in Neg. Cable Trays | 58d? | 2004-07-14 | 2004-10-01 |  | 416d |  | finish no earlier than 2004-10-01 |
| 13 | 12 | Pipe in Pos. Cable Trays | 53d? | 2004-09-15 | 2004-11-26 |  | 376d |  | finish no earlier than 2004-11-26 |
| 14 | 13 | Monunt Posts Pos. ME/RE | 11d? | 2004-12-01 | 2004-12-15 |  | 363d |  | finish no earlier than 2004-12-15 |
| 15 | 14 | Mount Posts Neg ME/RE | 11d? | 2005-01-10 | 2005-01-24 |  | 335d |  | finish no earlier than 2005-01-24 |
| 16 | 15 | Test Inst. ME1/2 under HE | 11d? | 2004-12-01 | 2004-12-15 |  | 363d |  | finish no earlier than 2004-12-15 |
| 17 | 16 | Lay ME/RE1/1 Pos Cables | 11d? | 2005-02-01 | 2005-02-15 |  | 319d |  | finish no earlier than 2005-02-15 |
| 18 | 17 | Lay ME/RE1/1 Neg Cables | 11d? | 2005-03-15 | 2005-03-29 |  | 289d |  | finish no earlier than 2005-03-29 |
| 19 | 18 | Install 'Z' Stops | 23d? | 2004-12-15 | 2005-01-14 |  | 341d |  | finish no earlier than 2005-01-14 |
| 20 | 19 | Inst. RE1/2 Pos. Near Yoke | 11d? | 2005-01-12 | 2005-01-26 | 4, 16 | 333d |  | start no earlier than 2005-01-12 |
| 21 | 20 | Inst. RE1/3 Pos. N. Yoke | 16d? | 2005-02-01 | 2005-02-22 | 10 | 314d |  | finish no earlier than 2005-02-22 |
| 22 | 21 | Gap delivery RE2/2 & 3 Neg. | 9d? | 2004-10-01 | 2004-10-13 |  | 285d | 121d | finish no earlier than 2004-10-13 |
| 23 | 22 | Gap delivery RE2/2 & 3 Pos. | 9d? | 2004-12-01 | 2004-12-13 |  | 277d | 121d | finish no earlier than 2004-12-13 |
| 24 | 23 | Tested RE2/2 & 2/3 Neg | 42d? | 2005-04-01 | 2005-05-30 | 22 | 164d | 1d | finish no earlier than 2005-05-30 |
| 25 | 24 | Delivery from PK (Neg.) | 11d? | 2005-06-01 | 2005-06-15 | 24 | 163d | 27d | finish no earlier than 2005-06-15 |
| 26 | 25 | Tested RE2/2 & 2/3 Pos. | 43d? | 2005-06-01 | 2005-07-29 | 23 | 156d | 0d | finish no earlier than 2005-07-29 |
| 27 | 26 | Deivery from PK (Pos.) | 10d? | 2005-08-01 | 2005-08-12 | 26 | 156d | 20d | finish no earlier than 2005-08-12 |
| 28 | 27 | Inst. RE1/2 Pos. Off Yoke | 35d? | 2006-02-06 | 2006-03-24 |  | 0d |  | finish no earlier than 2006-03-24 |
| 29 | 28 | Inst. RE1/3 Pos. Off Yoke | 35d? | 2006-02-06 | 2006-03-24 |  | 0d |  | finish no earlier than 2006-03-24 |
| 30 | 29 | Inst. RE1/2 Neg. Off Yoke | 31d? | 2006-03-27 | 2006-05-08 | 29 | 0d |  | finish no earlier than 2006-05-08 |
| 31 | 30 | Inst. RE1/3 Neg. Off Yoke | 31d? | 2006-03-27 | 2006-05-08 | 28 | 0d |  |  |
| 32 | 31 | Inst. RE1/2 Neg. Near Yoke | 11d? | 2006-02-13 | 2006-02-27 | 5 | 50d |  | finish no earlier than 2006-02-27 |
| 33 | 32 | Inst. RE1/3 Neg. Near Yoke | 16d? | 2006-03-01 | 2006-03-22 | 11 | 33d |  | finish no earlier than 2006-03-22 |
| 34 | 33 | Inst. RE2/2 &2/3 Neg | 35d? | 2005-07-25 | 2005-09-09 | 25 | 136d | 0d | finish no earlier than 2005-09-09 |
| 35 | 34 | Inst RE2/2 & 2/3 Pos. | 35d? | 2005-09-12 | 2005-10-28 | 34, 27 | 136d |  | finish no earlier than 2005-10-28 |
